Schedule from MS Project, 2018-02-15 to 2018-04-27, 7.5 hours a day.

## Calendars

- Standard: Mon-Fri 08:00-12:00, 13:00-17:00; Sat-Sun off.
- Interview calendar: Mon-Fri 08:00-12:00, 13:00-17:00; Sat-Sun off. Exceptions (off unless hours are given): 2018-02-26 to 2018-03-01 (SPE meeting), 2018-03-20 to 2018-03-22 (WEAVE Board), 2018-03-26 to 2018-03-30 (Semana santa), 2018-04-24 (Marc).

## Resources

| Resource |
| --- |
| Don Carlos |
| Montse |
| Kevin |
| Marc |

## Schedule

| ID | Task | Type | Duration | Start | Finish | Predecessors | Total slack | Free slack | Constraint | Calendar | Resources | Work |
| --- | --- | --- | --- | --- | --- | --- | --- | --- | --- | --- | --- | --- |
| 1 | Closing date | milestone, manual | 1d | 2018-02-15 | 2018-02-15 |  |  |  |  | Interview calendar |  |  |
| 2 | Shortlisting |  | 18d | 2018-02-16 | 2018-03-16 | 1 | 0.13d | 0d |  | Interview calendar | Don Carlos; Kevin; Marc | 405h |
| 3 | Meeting preparation |  | 1d | 2018-03-16 | 2018-03-19 | 2 | 0.13d | 0d |  | Interview calendar | Don Carlos | 7.5h |
| 4 | Meeting |  | 1h | 2018-03-19 | 2018-03-19 | 3 | 0.13d | 0d |  | Interview calendar | Don Carlos; Kevin; Marc; Montse | 4h |
| 5 | Arrange interviews |  | 19d | 2018-03-19 | 2018-04-25 | 4 | 0.13d | 0d |  | Interview calendar | Montse | 142.5h |
| 6 | Interview preparation |  | 19h | 2018-03-19 | 2018-04-03 | 3 | 18.35d |  |  | Interview calendar | Montse | 19h |
| 7 | Meeting |  | 2h | 2018-04-25 | 2018-04-25 | 5 | 0.13d | 0d |  | Interview calendar | Don Carlos; Kevin; Marc; Montse | 8h |
| 8 | Interview |  | 1d | 2018-04-26 | 2018-04-26 | 7 | 0.13d |  |  | Interview calendar | Don Carlos; Kevin; Marc; Montse | 30h |
| 9 | Trip to ORM |  | 1d | 2018-04-27 | 2018-04-27 | 8 | 0d |  | start no earlier than 2018-04-27 | Interview calendar | Don Carlos | 7.5h |
